# Salado Creek Crossing

Schedule from MS Project, 2010-01-04 to 2024-09-03, status date 2018-03-14.

## Calendars

- SAWS Standard Calendar: Mon-Fri 08:00-12:00, 13:00-17:00; Sat-Sun off. Exceptions (off unless hours are given): 2010-01-01 to 2034-01-01 (Holiday - New Year's Day, recurring), 2010-01-18 to 2034-01-16 (Holiday - MLK Day, recurring), 2010-04-23 to 2034-04-28 (Holiday - Fiesta, recurring), 2010-05-31 to 2034-05-29 (Holiday - Memorial Day, recurring), 2010-07-04 to 2034-07-04 (Holiday - Independence Day, recurring), 2010-11-25 to 2034-11-23 (Holiday - Thanksgiving, recurring), 2010-11-26 to 2034-11-24 (Holiday - Day After Thanksgiving, recurring), 2010-12-24 to 2034-12-24 (Holiday - Christmas Eve, recurring), 2010-12-25 to 2034-12-25 (Holiday - Christmas, recurring), 2010-12-31 to 2034-12-31 (Holiday - New Year's Eve, recurring), 2017-09-04 to 2041-09-02 (Holiday - Labor Day, recurring), 2017-12-26 to 2017-12-29 (SAWS Holiday - Christmas 2017), 2019-11-29 (Holiday - Day After Thanksgiving (5th week), recurring).

## Resources

| Resource | Group |
| --- | --- |
| Orlando Cruz | SAWS Pipelines - Capacity |
| Patrick O'Connor | SAWS Pipelines - Capacity |
| Sandra Gomez | SAWS Pipelines - Capacity |
| Abel Ramirez | SAWS Pipelines - Capacity |
| Noel Martin | SAWS Pipelines - Capacity |
| Luis Moran | SAWS Pipelines - Capacity |
| Juan Gomez | SAWS Pipelines - Capacity |
| Eddie Ibarra | SAWS Pipelines - Capacity |
| Gail Hamrick-Pigg | SAWS Pipelines - Capacity |
| Joshua Garcia | SAWS Pipelines - Capacity |
| Ryan Sowa | Kimley-Horn & Associates |
| Jeff Farnsworth | Kimley-Horn & Associates |
| Kendall Nesmith | Kimley-Horn & Associates |
| Nathan Cobler | Kimley-Horn & Associates |
| Gaby Mena | Kimley-Horn & Associates |
| Mario Valdez | Kimley-Horn & Associates |
| Ron Mick | BGE |
| Abdel Hamed | BGE |
| Steven Thai | BGE |
| Rick Myrick | Merrick & Company |
| Keller Drozdick | Merrick & Company |
| Chris Boentges | K Friese |
| Daniel Furdock | Kimley-Horn & Associates |
| Danielle Gross | Kimley-Horn & Associates |
| Dale Murphy | K Friese |
| Michael Persyn | K Friese |
| Andrew Fischer | K Friese |
| Tyler Kierstead | K Friese |
| David Gonzales | SAWS Construction |
| Quintin Pollock | SAWS Construction |
| Frank Aniol | SAWS Construction |
| Bruce Haby | SAWS Corporate Real Estate |
| Sunny Burlew | SAWS Corporate Real Estate |
| David Sanchez | SAWS Corporate Real Estate |
| Other | Other |
| Diana Woltersdorf | SAWS Contracting |
| Fred Flores | SAWS Contracting |
| Janie Powell | SAWS Contracting |
| Kat Price | SAWS Operations Support |
| Adam Aranda | SAWS Operations Support |
| Cristian Moza | SAWS Master Planning |
| Matt Schorsch | SAWS Master Planning |
| Philip Campos | SAWS Contracting |
| Phillip Vasquez | SAWS GIS MAPPING |
| Roger Sanchez | SAWS Construction |
| Ramon Guerra | SAWS Construction |
| Richard Ker | SAWS Construction |
| David Bennett | Freese and Nichols |
| David Marotta | Freese and Nichols |
| Nancy Gonzalez Figueroa | SAWS Construction |
| Nathaniel Virdell | SAWS Construction |
| Jessica George | SAWS Pipelines - Capacity |
| Mark Brewton | SAWS Legal |
| Scott Oliver | SAWS Legal |
| Esther Harrah | SAWS Construction |
| Julian Perales | SAWS Construction |
| John Reynolds | SAWS Legal |
| Nancy Belinsky | SAWS Legal |
| Angelica Mata | SAWS Contracting |
| Diana Starkey | SAWS Contracting |
| Stella Manzello | SAWS Contracting |
| Jessica Goforth | SAWS Contracting |
| Roxanne Lockhart | SAWS Contracting |
| Lindsay Esquivel | SAWS Contracting |
| Johnathan Miranda | SAWS Contracting |
| Rebekah Cramblitt | Kimley-Horn & Associates |
| Noel |  |
| Eduardo Anzueto | SAWS Pipelines - Capacity |
| Emmanuel Villegas | SAWS Pipelines - Capacity |

## Schedule

| ID | WBS | Task | Type | Duration | Start | Finish | Predecessors | Total slack | Free slack | Constraint | Baseline Complete |
| --- | --- | --- | --- | --- | --- | --- | --- | --- | --- | --- | --- |
| 1 | 1 | **Project Name (Template) Spec Design, RFCSP Construction** |  | 3694d | 2010-01-04 | 2024-09-03 |  | 0d |  |  | Tue 9/3/24 |
| 2 | 1.1 | **INITIATION** |  | 167d | 2018-07-18 | 2019-03-19 |  | 1355d |  |  | Tue 3/19/19 |
| 3 | 1.1.1 | Planning Services Defines New Project (clear scope w/ map w/ precise start + end points) |  | 21d | 2018-07-18 | 2018-08-15 |  | 1355d | 0d | finish no earlier than 2018-08-15 | Wed 8/15/18 |
| 4 | 1.1.2 | Planning Services creates Project Proposal in CPMS and includes all impacted asset IDs |  | 3d | 2018-08-16 | 2018-08-20 | 3 | 1355d | 0d |  | Mon 8/20/18 |
| 5 | 1.1.3 | Budgeting Team develops Preliminary Budget |  | 3d | 2018-08-21 | 2018-08-23 | 4 | 1355d | 0d |  | Thu 8/23/18 |
| 6 | 1.1.4 | Management Assigns Project |  | 1d | 2018-08-24 | 2018-08-24 | 5 | 1355d | 0d |  | Fri 8/24/18 |
| 7 | 1.1.5 | SAWS Engr collects as-built and other historical data |  | 3d | 2018-08-27 | 2018-08-29 | 6 | 1355d | 0d |  | Wed 8/29/18 |
| 8 | 1.1.6 | SAWS Engr confers with Planning and others to confirm Scope of Project |  | 5d | 2018-08-30 | 2018-09-06 | 7 | 1355d | 0d |  | Thu 9/6/18 |
| 9 | 1.1.7 | SAWS Engr develops Initial Schedule and Budget |  | 5d | 2018-09-07 | 2018-09-13 | 8 | 1355d | 0d |  | Thu 9/13/18 |
| 10 | 1.1.8 | SAWS Engr Identifies Initial Project Conflicts |  | 5d | 2018-09-14 | 2018-09-20 | 9 | 1355d | 0d |  | Thu 9/20/18 |
| 11 | 1.1.9 | SAWS Engr drafts Charter and submits for Management Approval |  | 3d | 2018-09-21 | 2018-09-25 | 10 | 1355d | 0d |  | Tue 9/25/18 |
| 12 | 1.1.10 | SAWS Engr converts to Implementation Project in CPMS |  | 1d | 2018-09-26 | 2018-09-26 | 11 | 1355d | 0d |  | Wed 9/26/18 |
| 13 | 1.1.11 | SAWS Management Reviews and Approves Charter |  | 10d | 2018-09-27 | 2018-10-10 | 12 | 1355d | 0d |  | Wed 10/10/18 |
| 14 | 1.1.12 | Program Planning Confirms CIP funding and Transfers Funds to Project |  | 5d | 2018-10-11 | 2018-10-17 | 13 | 1355d | 0d |  | Wed 10/17/18 |
| 15 | 1.1.13 | Project Funding Complete SAWS Engr documents Milestone | milestone | 0d | 2018-10-17 | 2018-10-17 | 14 | 1355d | 0d |  | Wed 10/17/18 |
| 16 | 1.1.14 | **Award of Design Contract (Specified)** |  | 102d | 2018-10-18 | 2019-03-19 |  | 1355d |  |  | Tue 3/19/19 |
| 17 | 1.1.14.1 | SAWS Engr drafts RFQ scope document |  | 2d | 2018-10-18 | 2018-10-19 | 15 | 1355d | 0d | start no earlier than 2017-04-04 | Fri 10/19/18 |
| 18 | 1.1.14.2 | SAWS Engr submits RFQ scope document for Manager Review |  | 1d | 2018-10-22 | 2018-10-22 | 17 | 1355d | 0d | start no earlier than 2017-05-05 | Mon 10/22/18 |
| 19 | 1.1.14.3 | Manager Approves scope document for RFQ |  | 2d | 2018-10-23 | 2018-10-24 | 18 | 1355d | 0d | start no earlier than 2017-02-14 | Wed 10/24/18 |
| 20 | 1.1.14.4 | SAWS Engr starts CPMS workflow for Solicitation |  | 1d | 2018-10-25 | 2018-10-25 | 19 | 1355d | 0d | start no earlier than 2017-02-28 | Thu 10/25/18 |
| 21 | 1.1.14.5 | SAWS Contracting Develops complete RFQ document and Issues RFQ |  | 10d | 2018-10-26 | 2018-11-08 | 20 | 1355d | 0d | start no earlier than 2017-03-01 | Thu 11/8/18 |
| 22 | 1.1.14.6 | Consultants Review RFQ and Prepare Responses |  | 22d | 2018-11-09 | 2018-12-12 | 21 | 1355d | 0d | start no earlier than 2017-03-01 | Wed 12/12/18 |
| 23 | 1.1.14.7 | Contracting and SAWS Engr conduct pre-submittal meeting (if applicable) |  | 1d | 2018-11-20 | 2018-11-20 | 21FS+7d | 1453d |  | start no earlier than 2017-02-28 | Tue 11/20/18 |
| 24 | 1.1.14.8 | Consultants Responses Due to SAWS Contracting |  | 1d | 2018-12-13 | 2018-12-13 | 22 | 1355d | 0d | start no earlier than 2017-02-28 | Thu 12/13/18 |
| 25 | 1.1.14.9 | Technical Committee Evaluates Submittals |  | 10d | 2018-12-14 | 2019-01-02 | 24 | 1355d | 0d | start no earlier than 2017-03-01 | Wed 1/2/19 |
| 26 | 1.1.14.10 | Selection Committee Selects Consultant |  | 5d | 2019-01-03 | 2019-01-09 | 25 | 1423d |  | start no earlier than 2017-03-15 | Wed 1/9/19 |
| 27 | 1.1.14.11 | SAWS Engr drafts and submits Board Item (with blanks) |  | 3d | 2019-01-03 | 2019-01-07 | 25 | 1355d | 0d |  | Mon 1/7/19 |
| 28 | 1.1.14.12 | SAWS Engr Negotiates Rates with Consultant (Seek Consistency with Existing Contracts) |  | 3d | 2019-01-08 | 2019-01-10 | 27 | 1355d | 0d | start no earlier than 2017-03-15 | Thu 1/10/19 |
| 29 | 1.1.14.13 | SAWS Engr Negotiates Scope with Consultant |  | 7d | 2019-01-11 | 2019-01-22 | 28 | 1355d | 0d | start no earlier than 2017-03-15 | Tue 1/22/19 |
| 30 | 1.1.14.14 | SAWS Engr Negotiates Schedule with Consultant |  | 3d | 2019-01-23 | 2019-01-25 | 29 | 1355d | 0d | start no earlier than 2017-03-15 | Fri 1/25/19 |
| 31 | 1.1.14.15 | SAWS Engr Negotiates Fee with Consultant |  | 5d | 2019-01-28 | 2019-02-01 | 30 | 1355d | 0d |  | Fri 2/1/19 |
| 32 | 1.1.14.16 | SAWS Engr and Consultant Agree on Final Draft of Scope, Fee, and Schedule |  | 1d | 2019-02-04 | 2019-02-04 | 31 | 1355d | 0d | start no earlier than 2017-03-15 | Mon 2/4/19 |
| 33 | 1.1.14.17 | SAWS Engr submits Final Board Item |  | 1d | 2019-02-05 | 2019-02-05 | 32 | 1355d | 0d |  | Tue 2/5/19 |
| 34 | 1.1.14.18 | SAWS Engr starts Contract Workflow in CPMS |  | 1d | 2019-02-06 | 2019-02-06 | 33 | 1386d | 0d | start no earlier than 2017-03-15 | Wed 2/6/19 |
| 35 | 1.1.14.19 | SAWS Engr Manager Reviews (duration includes return for revisions) |  | 3d | 2019-02-07 | 2019-02-11 | 34 | 1386d | 0d | start no earlier than 2017-03-15 | Mon 2/11/19 |
| 36 | 1.1.14.20 | SAWS Contracting Reviews (duration includes return for revisions) |  | 10d | 2019-02-12 | 2019-02-25 | 35 | 1386d | 0d | start no earlier than 2017-03-15 | Mon 2/25/19 |
| 37 | 1.1.14.21 | SAWS Legal Reviews (duration includes return for revisions) |  | 5d | 2019-02-26 | 2019-03-04 | 36 | 1386d |  | start no earlier than 2017-03-15 | Mon 3/4/19 |
| 38 | 1.1.14.22 | Board Process |  | 20d | 2019-02-06 | 2019-03-05 | 33 | 1355d | 0d | start no earlier than 2017-03-15 | Tue 3/5/19 |
| 39 | 1.1.14.23 | Design Board Award (1st Tuesday of the Month) | milestone | 0d | 2019-03-05 | 2019-03-05 | 38 | 1355d | 0d |  | Tue 3/5/19 |
| 40 | 1.1.14.24 | Execute Design Contract |  | 10d | 2019-03-06 | 2019-03-19 | 39 | 1355d | 0d | start no earlier than 2017-08-01 | Tue 3/19/19 |
| 41 | 1.1.14.25 | Issue Design NTP | milestone | 0d | 2019-03-19 | 2019-03-19 | 40 | 1355d | 0d | start no earlier than 2017-06-15 | Tue 3/19/19 |
| 42 | 1.1.14.26 | Project Initiation Complete (SAWS Engr documents Milestone) | milestone | 0d | 2019-03-19 | 2019-03-19 | 41 | 1375d |  |  | Tue 3/19/19 |

| ID | WBS | Task | Type | Duration | Start | Finish | Predecessors | Total slack | Free slack | Baseline Complete |
| --- | --- | --- | --- | --- | --- | --- | --- | --- | --- | --- |
| 43 | 1.2 | **DESIGN** |  | 2976d | 2010-01-04 | 2021-10-28 |  | 718d |  | Thu 10/28/21 |
| 44 | 1.2.1 | **30% Design** |  | 2339d | 2010-01-04 | 2019-04-16 |  | 1355d |  | Tue 4/16/19 |
| 45 | 1.2.1.1 | Kickoff Meeting | milestone | 0d | 2019-03-19 | 2019-03-19 | 41 | 1355d | 0d | Tue 3/19/19 |
| 46 | 1.2.1.2 | SAWS Engr provides SAWS as-builts, block maps, televising to Consultant | milestone | 0d | 2019-03-19 | 2019-03-19 | 45FF | 1375d |  | Tue 3/19/19 |
| 47 | 1.2.1.3 | **Desktop Analysis** |  | 20d | 2019-03-20 | 2019-04-16 |  | 1355d |  | Tue 4/16/19 |
| 48 | 1.2.1.3.1 | Identify initial alignments and overall proposed area to be reviewed |  | 10d | 2019-03-20 | 2019-04-02 | 45 | 1355d | 0d | Tue 4/2/19 |
| 49 | 1.2.1.3.2 | Consultant Data Collection |  | 10d | 2019-03-20 | 2019-04-02 | 45 | 1365d |  | Tue 4/2/19 |
| 50 | 1.2.1.3.3 | Environmental & Endangered Species Compliance Review |  | 10d | 2019-04-03 | 2019-04-16 | 48 | 1355d |  | Tue 4/16/19 |
| 51 | 1.2.1.3.4 | Cultural Resources Review |  | 10d | 2019-04-03 | 2019-04-16 | 48 | 1355d |  | Tue 4/16/19 |
| 52 | 1.2.1.3.5 | Existing System Hydraulic Analysis |  | 10d | 2019-04-03 | 2019-04-16 | 48 | 1355d |  | Tue 4/16/19 |
| 53 | 1.2.1.4 | **Field Work** |  | 10d | 2010-01-04 | 2010-01-15 |  | 3684d |  | Fri 1/15/10 |
| 54 | 1.2.1.4.1 | Consultant Conducts Site Visits to Confirm Existing Conditions |  | 10d | 2010-01-04 | 2010-01-15 |  | 3684d |  | Fri 1/15/10 |
| 55 | 1.2.1.5 | **Alignment Analysis** |  | 37d | 2010-01-04 | 2010-02-24 |  | 2115d |  | Wed 2/24/10 |
| 56 | 1.2.1.5.1 | Alternative Alignment & Conceptual Analysis |  | 21d | 2010-01-04 | 2010-02-02 |  | 2115d | 0d | Tue 2/2/10 |
| 57 | 1.2.1.5.2 | Generate List of Required Environmental & Cultural Investigations |  | 5d | 2010-02-03 | 2010-02-09 | 56 | 3668d |  | Tue 2/9/10 |
| 58 | 1.2.1.5.3 | Generate List of Required Permits (Permit Log) |  | 5d | 2010-02-03 | 2010-02-09 | 56 | 3668d |  | Tue 2/9/10 |
| 59 | 1.2.1.5.4 | Generate List of Utilities and Stakeholders (Coordination Log) |  | 5d | 2010-02-03 | 2010-02-09 | 56 | 3668d |  | Tue 2/9/10 |
| 60 | 1.2.1.5.5 | Preliminary Geotech Planning |  | 5d | 2010-02-03 | 2010-02-09 | 56 | 3668d |  | Tue 2/9/10 |
| 61 | 1.2.1.5.6 | Preliminary SUE Planning |  | 5d | 2010-02-03 | 2010-02-09 | 56 | 2115d | 0d | Tue 2/9/10 |
| 62 | 1.2.1.5.7 | Consultant prepares Preliminary Engineering Report (PER) |  | 10d | 2010-02-10 | 2010-02-23 | 61 | 2115d | 0d | Tue 2/23/10 |
| 63 | 1.2.1.5.8 | Consultant Submits PER |  | 1d | 2010-02-24 | 2010-02-24 | 62 | 2115d | 0d | Wed 2/24/10 |
| 64 | 1.2.1.6 | **SAWS Review of 30% Design** |  | 12d | 2010-02-25 | 2010-03-12 |  | 2115d |  | Fri 3/12/10 |
| 65 | 1.2.1.6.1 | SAWS Team Distributes to Reviewers |  | 1d | 2010-02-25 | 2010-02-25 | 63 | 2115d | 0d | Thu 2/25/10 |
| 66 | 1.2.1.6.2 | Consultant Prepares for PER Workshop |  | 2d | 2010-02-25 | 2010-02-26 | 63 | 3654d | 0d | Fri 2/26/10 |
| 67 | 1.2.1.6.3 | Consultant Conducts PER Workshop |  | 1d | 2010-03-01 | 2010-03-01 | 66 | 3654d |  | Mon 3/1/10 |
| 68 | 1.2.1.6.4 | SAWS Reviews PER |  | 5d | 2010-02-26 | 2010-03-04 | 65 | 2115d | 0d | Thu 3/4/10 |
| 69 | 1.2.1.6.5 | SAWS provides comments to Consultant |  | 1d | 2010-03-05 | 2010-03-05 | 68 | 2115d | 0d | Fri 3/5/10 |
| 70 | 1.2.1.6.6 | Consultant Reponds to SAWS Comments and Submits FINAL PER |  | 3d | 2010-03-08 | 2010-03-10 | 69 | 2115d | 0d | Wed 3/10/10 |
| 71 | 1.2.1.6.7 | SAWS Reviews FINAL PER, if acceptable then 30% Design Complete |  | 1d | 2010-03-11 | 2010-03-11 | 70 | 2115d | 0d | Thu 3/11/10 |
| 72 | 1.2.1.6.8 | 30% Design Complete (SAWS Engr documents Milestone) | milestone | 0d | 2010-03-11 | 2010-03-11 | 71 | 2115d | 0d | Thu 3/11/10 |
| 73 | 1.2.1.6.9 | SAWS Engr Issues 60% Design NTP (if Final PER acceptable) |  | 1d | 2010-03-12 | 2010-03-12 | 72 | 2115d |  | Fri 3/12/10 |

| ID | WBS | Task | Type | Duration | Start | Finish | Predecessors | Total slack | Free slack | Constraint | Baseline Complete |
| --- | --- | --- | --- | --- | --- | --- | --- | --- | --- | --- | --- |
| 74 | 1.2.2 | **60% Design** |  | 102d | 2018-08-03 | 2019-01-02 |  | 0d |  |  | Wed 1/2/19 |
| 75 | 1.2.2.1 | Procure Right-of-Entries for Survey, Geotech, SUE, etc |  | 22d | 2018-08-03 | 2018-09-04 | 73 | 0d |  | start no earlier than 2018-08-03 | Tue 9/4/18 |
| 76 | 1.2.2.2 | Perform Design Survey |  | 21d | 2018-09-05 | 2018-10-03 | 75 | 1477d | 0d |  | Wed 10/3/18 |
| 77 | 1.2.2.3 | Perform Geotechnical Bores & Prepare Report |  | 21d | 2018-09-05 | 2018-10-03 | 75 | 1487d |  |  | Wed 10/3/18 |
| 78 | 1.2.2.4 | Perform Subsurface Utility Exploration & Prepare Report |  | 21d | 2018-09-05 | 2018-10-03 | 75 | 1487d |  |  | Wed 10/3/18 |
| 79 | 1.2.2.5 | Perform Environmental + Endangered Species Studies and Prepare Reports (some may require survey at different time of year, e.g. Golden Cheeked Warbler nests March-June) |  | 30d | 2018-09-05 | 2018-10-16 | 75 | 0d |  |  | Tue 10/16/18 |
| 80 | 1.2.2.6 | Perform Cultural/Archeological Studies and Prepare Reports |  | 30d | 2018-09-05 | 2018-10-16 | 75 | 0d |  |  | Tue 10/16/18 |
| 81 | 1.2.2.7 | Coordination Meetings with Utilities, Permit Agencies, and other Stakeholders |  | 10d | 2018-10-04 | 2018-10-17 | 76 | 1477d | 0d |  | Wed 10/17/18 |
| 82 | 1.2.2.8 | Update Utility and Stakeholder Coordination Log |  | 10d | 2018-10-04 | 2018-10-17 | 81FF | 1477d |  |  | Wed 10/17/18 |
| 83 | 1.2.2.9 | Prepare 60% Design Documents |  | 28d | 2018-10-17 | 2018-11-27 | 79, 80 | 0d |  |  | Tue 11/27/18 |
| 84 | 1.2.2.10 | Submit 60% Design Documents to SAWS (Plans,Specs,OPCC,Signed Checklist) |  | 1d | 2018-11-28 | 2018-11-28 | 83 | 0d |  | start no earlier than 2018-10-01 | Wed 11/28/18 |
| 85 | 1.2.2.11 | **SAWS Review of 60% Design** |  | 21d | 2018-11-29 | 2019-01-02 | 84 | 0d |  |  | Wed 1/2/19 |
| 86 | 1.2.2.11.1 | SAWS Team Distributes to Reviewers |  | 1d | 2018-11-29 | 2018-11-29 |  | 0d |  |  | Thu 11/29/18 |
| 87 | 1.2.2.11.2 | Consultant Prepares for 60% Workshop |  | 3d | 2018-11-29 | 2018-12-03 | 84 | 1445d | 0d |  | Mon 12/3/18 |
| 88 | 1.2.2.11.3 | Consultant Conducts 60% Workshop (very brief overview of project (2 minutes max) followed by detailed discussion and QA session on unique aspects of or questions about plans/specs) |  | 1d | 2018-12-04 | 2018-12-04 | 87 | 1445d |  |  | Tue 12/4/18 |
| 89 | 1.2.2.11.4 | SAWS Review of 60% Design |  | 10d | 2018-11-30 | 2018-12-13 | 86 | 0d |  |  | Thu 12/13/18 |
| 90 | 1.2.2.11.5 | SAWS provides comments to Consultant |  | 1d | 2018-12-14 | 2018-12-14 | 89 | 0d |  |  | Fri 12/14/18 |
| 91 | 1.2.2.11.6 | Consultant Reviews Comments |  | 2d | 2018-12-17 | 2018-12-18 | 90 | 0d |  |  | Tue 12/18/18 |
| 92 | 1.2.2.11.7 | Prepare Responses to Comments and Letter affirming that revisions will be incorporated into 90% Design submittal |  | 3d | 2018-12-19 | 2018-12-21 | 91 | 0d |  |  | Fri 12/21/18 |
| 93 | 1.2.2.11.8 | Consultant Submits Responses |  | 1d | 2018-12-26 | 2018-12-26 | 92 | 0d |  |  | Wed 12/26/18 |
| 94 | 1.2.2.11.9 | SAWS Reviews Consultant Response, if acceptable then 60% Design Complete |  | 2d | 2018-12-27 | 2018-12-28 | 93 | 0d |  |  | Fri 12/28/18 |
| 95 | 1.2.2.11.10 | 60% Design Complete (SAWS Engr documents Milestone) | milestone | 0d | 2018-12-28 | 2018-12-28 | 94 | 0d |  |  | Fri 12/28/18 |
| 96 | 1.2.2.11.11 | SAWS Engr Issues 90% Design NTP |  | 1d | 2019-01-02 | 2019-01-02 | 95 | 1265d | 0d |  | Wed 1/2/19 |
| 97 | 1.2.3 | **90% Design** |  | 581d | 2018-10-17 | 2021-02-16 |  | 897d |  |  | Tue 2/16/21 |
| 98 | 1.2.3.1 | Walk Alignment with Inspectors |  | 2d | 2019-01-03 | 2019-01-04 | 96 | 1387d | 43d |  | Fri 1/4/19 |
| 99 | 1.2.3.2 | Prepare 90% Design Documents |  | 60d | 2019-01-03 | 2019-03-28 | 96 | 1265d | 0d |  | Thu 3/28/19 |
| 100 | 1.2.3.3 | Coordination Meetings with Utilities, Permit Agencies, and other Stakeholders |  | 10d | 2019-02-22 | 2019-03-07 | 99FF-15d | 1344d | 0d |  | Thu 3/7/19 |
| 101 | 1.2.3.4 | Update Utility and Stakeholder Coordination Log |  | 15d | 2019-02-15 | 2019-03-07 | 98FF, 100FF | 1344d | 0d |  | Thu 3/7/19 |
| 102 | 1.2.3.5 | Submit 90% Design Documents to SAWS (Plans,Specs (with draft Front Ends),OPCC,Signed Checklist) |  | 1d | 2019-03-08 | 2019-03-08 | 101 | 1344d | 0d |  | Fri 3/8/19 |

| ID | WBS | Task | Type | Duration | Start | Finish | Predecessors | Total slack | Free slack | Baseline Complete |
| --- | --- | --- | --- | --- | --- | --- | --- | --- | --- | --- |
| 103 | 1.2.3.6 | **SAWS Review of 90% Design** |  | 38d | 2019-03-11 | 2019-05-02 |  | 1344d |  | Thu 5/2/19 |
| 104 | 1.2.3.6.1 | SAWS Team Distributes to Reviewers (including Construction Dept) |  | 1d | 2019-03-11 | 2019-03-11 | 102 | 1344d | 0d | Mon 3/11/19 |
| 105 | 1.2.3.6.2 | Consultant Prepares for 90% Workshop |  | 3d | 2019-03-11 | 2019-03-13 | 102 | 1378d | 0d | Wed 3/13/19 |
| 106 | 1.2.3.6.3 | Consultant Conducts 90% Workshop (very brief overview of project (2 minutes max) followed by detailed discussion and QA session on unique aspects of or questions about plans/specs) |  | 1d | 2019-03-14 | 2019-03-14 | 105 | 1378d |  | Thu 3/14/19 |
| 107 | 1.2.3.6.4 | SAWS Review of 90% Design |  | 10d | 2019-03-12 | 2019-03-25 | 104 | 1344d | 0d | Mon 3/25/19 |
| 108 | 1.2.3.6.5 | SAWS provides comments to Consultant |  | 1d | 2019-03-26 | 2019-03-26 | 107 | 1344d | 0d | Tue 3/26/19 |
| 109 | 1.2.3.6.6 | Consultant Reviews Comments |  | 2d | 2019-03-27 | 2019-03-28 | 108 | 1344d | 0d | Thu 3/28/19 |
| 110 | 1.2.3.6.7 | Prepare Responses to Comments and Final 90% Submittal |  | 15d | 2019-03-29 | 2019-04-18 | 109 | 1344d | 0d | Thu 4/18/19 |
| 111 | 1.2.3.6.8 | Consultant Submits Responses w/Final 90% Design Plans, Specs, OPCC |  | 1d | 2019-04-19 | 2019-04-19 | 110 | 1344d | 0d | Fri 4/19/19 |
| 112 | 1.2.3.6.9 | SAWS Engr Verifies 90% Documents Acceptable |  | 3d | 2019-04-22 | 2019-04-24 | 111 | 1344d | 0d | Wed 4/24/19 |
| 113 | 1.2.3.6.10 | 90% Design Complete (SAWS Engr documents Milestone) | milestone | 0d | 2019-04-24 | 2019-04-24 | 112 | 1344d | 0d | Wed 4/24/19 |
| 114 | 1.2.3.6.11 | Develop Customer Address List and Area Exhibit for Construction Public Meeting |  | 5d | 2019-04-25 | 2019-05-02 | 113 | 1344d | 0d | Thu 5/2/19 |
| 115 | 1.2.3.6.12 | Provide Address List to External Relations so they can Arrange Public Meeting | milestone | 0d | 2019-05-02 | 2019-05-02 | 114 | 1344d |  | Thu 5/2/19 |
| 116 | 1.2.3.7 | **Permitting** |  | 581d | 2018-10-17 | 2021-02-16 |  | 897d |  | Tue 2/16/21 |
| 117 | 1.2.3.7.1 | **FEDERAL** |  | 213d | 2018-10-17 | 2019-08-23 |  | 1265d |  | Fri 8/23/19 |
| 118 | 1.2.3.7.1.1 | Army Corp of Engineers Permit (NWP12 w/o PCN, NWP12 w PCN, or 404) |  | 120d | 2018-10-17 | 2019-04-11 | 79 | 1313d | 0d | Thu 4/11/19 |
| 119 | 1.2.3.7.1.2 | US Fish & Wildlife Service (USFWS) Survey & Report (Karst, Birds, etc) |  | 120d | 2018-10-17 | 2019-04-11 | 79 | 1313d | 0d | Thu 4/11/19 |
| 120 | 1.2.3.7.1.3 | Railroad Crossing Agreement (tunnels under track) |  | 62d | 2019-03-29 | 2019-06-26 | 99 | 1306d |  | Wed 6/26/19 |
| 121 | 1.2.3.7.1.4 | Railroad Encroachment Agreement (survey or construction within 50ft of track) |  | 103d | 2019-03-29 | 2019-08-23 | 99 | 1265d |  | Fri 8/23/19 |
| 122 | 1.2.3.7.2 | **STATE** |  | 165d | 2018-10-17 | 2019-06-17 |  | 1313d |  | Mon 6/17/19 |
| 123 | 1.2.3.7.2.1 | THC - Texas Historical Commission Permit |  | 30d | 2018-10-17 | 2018-11-29 | 80 | 1403d | 0d | Thu 11/29/18 |
| 124 | 1.2.3.7.2.2 | TWDB Loan (requires Environmental + Cultural reports + ACoE and USFWS review) |  | 45d | 2019-04-12 | 2019-06-17 | 79, 118, 119, 123 | 1313d |  | Mon 6/17/19 |
| 125 | 1.2.3.7.3 | **COUNTY** |  | 180d | 2020-05-29 | 2021-02-16 |  | 897d |  | Tue 2/16/21 |
| 126 | 1.2.3.7.3.1 | SARA Creek Crossing or Banks (see Easements) |  | 180d | 2020-05-29 | 2021-02-16 | 150, 149 | 897d |  | Tue 2/16/21 |

| ID | WBS | Task | Type | Duration | Start | Finish | Predecessors | Total slack | Free slack | Constraint | Baseline Complete |
| --- | --- | --- | --- | --- | --- | --- | --- | --- | --- | --- | --- |
| 127 | 1.2.3.7.4 | **CITY** |  | 128d | 2018-10-17 | 2019-04-23 |  | 1350d |  |  | Tue 4/23/19 |
| 128 | 1.2.3.7.4.1 | CoSA Office of Historic Preservation (OHP) Certificate of Appropriateness |  | 5d | 2018-11-30 | 2018-12-06 | 123 | 1443d |  |  | Thu 12/6/18 |
| 129 | 1.2.3.7.4.2 | CoSA Tree Permit |  | 120d | 2018-10-17 | 2019-04-11 | 79 | 1358d |  |  | Thu 4/11/19 |
| 130 | 1.2.3.7.4.3 | CoSA Habitat Compliance Form |  | 60d | 2018-10-17 | 2019-01-16 | 79 | 1418d |  |  | Wed 1/16/19 |
| 131 | 1.2.3.7.4.4 | CoSA Parks JUA (see Easements) |  | 10d | 2019-04-10 | 2019-04-23 | 149 | 1350d |  |  | Tue 4/23/19 |
| 132 | 1.2.3.7.4.5 | CoSA Stormwater Permit (for bldg or site work) |  | 10d | 2019-02-22 | 2019-03-07 | 100FF | 1383d |  |  | Thu 3/7/19 |
| 133 | 1.2.3.7.4.6 | Coordinate CoSA ROW Permit (actual permit by contractor) |  | 10d | 2019-02-22 | 2019-03-07 | 100FF | 1383d |  |  | Thu 3/7/19 |
| 134 | 1.2.3.7.5 | Update Permit Log as Design Progresses |  | 28d | 2018-10-17 | 2018-11-27 | 79, 80 | 1450d |  |  | Tue 11/27/18 |
| 135 | 1.2.4 | **Easements** |  | 69d | 2019-01-02 | 2019-04-09 |  | 0d |  |  | Tue 4/9/19 |
| 136 | 1.2.4.1 | Consultant develops list of easements (w/ NCBs for each easement) and strip map illustrating them on alignment |  | 5d | 2019-01-02 | 2019-01-08 | 95 | 0d |  |  | Tue 1/8/19 |
| 137 | 1.2.4.2 | Consultant submits list, strip map, and NCBs for review | milestone | 0d | 2019-01-08 | 2019-01-08 | 136 | 0d |  |  | Tue 1/8/19 |
| 138 | 1.2.4.3 | SAWS Engr + CRE Reviews Strip Map, List, NCBs |  | 7d | 2019-01-09 | 2019-01-17 | 137 | 0d |  |  | Thu 1/17/19 |
| 139 | 1.2.4.4 | SAWS provides comments | milestone | 0d | 2019-01-17 | 2019-01-17 | 138 | 0d |  |  | Thu 1/17/19 |
| 140 | 1.2.4.5 | Consultant + SAWS Engr finalize Strip Map, List , NCBs + provide to CRE, CRE then obtains Board and City Council approval of a necessity ordinance for project |  | 7d | 2019-01-18 | 2019-01-29 | 139 | 0d |  |  | Tue 1/29/19 |
| 141 | 1.2.4.6 | Consultant Drafts P&FN |  | 15d | 2019-01-30 | 2019-02-19 | 140 | 0d |  |  | Tue 2/19/19 |
| 142 | 1.2.4.7 | Consultant submits P&FN for review | milestone | 0d | 2019-02-19 | 2019-02-19 | 141 | 0d |  |  | Tue 2/19/19 |
| 143 | 1.2.4.8 | SAWS Engr Reviews P&FN |  | 5d | 2019-02-20 | 2019-02-26 | 142 | 0d |  |  | Tue 2/26/19 |
| 144 | 1.2.4.9 | SAWS provides comments | milestone | 0d | 2019-02-26 | 2019-02-26 | 143 | 0d |  |  | Tue 2/26/19 |
| 145 | 1.2.4.10 | Consultant revises & resubmits P&FN for review |  | 10d | 2019-02-27 | 2019-03-12 | 144 | 0d |  |  | Tue 3/12/19 |
| 146 | 1.2.4.11 | SAWS CRE Reviews P&FN |  | 15d | 2019-03-13 | 2019-04-02 | 145 | 0d |  |  | Tue 4/2/19 |
| 147 | 1.2.4.12 | SAWS provides comments | milestone | 0d | 2019-04-02 | 2019-04-02 | 146 | 0d |  |  | Tue 4/2/19 |
| 148 | 1.2.4.13 | Consultant revises and sign/seals P&FN |  | 5d | 2019-04-03 | 2019-04-09 | 147 | 0d |  |  | Tue 4/9/19 |
| 149 | 1.2.4.14 | Sealed Plat and Field Notes provided to Real Estate | milestone | 0d | 2019-04-09 | 2019-04-09 | 148 | 0d |  |  | Tue 4/9/19 |
| 150 | 1.2.5 | **SAWS Corporate Real Estate Process** |  | 283d | 2019-04-09 | 2020-05-28 | 149 | 0d |  |  | Thu 5/28/20 |
| 151 | 1.2.5.1 | **Real Estate Acquires Easements** |  | 131d | 2019-04-09 | 2019-10-15 |  | 0d |  |  | Tue 10/15/19 |
| 152 | 1.2.5.1.1 | CRE provides signed/sealed P&FN to appraiser | milestone | 0d | 2019-04-09 | 2019-04-09 | 149 | 0d |  |  | Tue 4/9/19 |
| 153 | 1.2.5.1.2 | CRE receives appraisal (1st takes 45 days, last takes 90) |  | 62d | 2019-04-10 | 2019-07-09 | 152 | 0d |  |  | Tue 7/9/19 |
| 154 | 1.2.5.1.3 | CRE issues 1st offer letter (based on appraisal w/LBoR) | milestone | 0d | 2019-07-09 | 2019-07-09 | 153 | 0d |  |  | Tue 7/9/19 |
| 155 | 1.2.5.1.4 | USPS delivers 1st offer letter (w/ Return Receipt) |  | 5d | 2019-07-10 | 2019-07-16 | 154 | 0d |  |  | Tue 7/16/19 |
| 156 | 1.2.5.1.5 | By law must allow 30 days from RECEIPT of 1st offer |  | 21d | 2019-07-17 | 2019-08-14 | 155 | 0d |  |  | Wed 8/14/19 |
| 157 | 1.2.5.1.6 | Time during which Engr team answers questions and CRE negotiates with landowner |  | 10d | 2019-08-15 | 2019-08-28 | 156 | 0d |  |  | Wed 8/28/19 |
| 158 | 1.2.5.1.7 | Meet with landowner if needed to refine easement terms, allow CRE to negotiate |  | 1d | 2019-08-29 | 2019-08-29 | 157 | 0d |  |  | Thu 8/29/19 |
| 159 | 1.2.5.1.8 | CRE + Engr meet to determine if further negotiation futile |  | 5d | 2019-08-30 | 2019-09-06 | 158 | 0d |  |  | Fri 9/6/19 |
| 160 | 1.2.5.1.9 | CRE issues Final offer letter (and prepares Board Item to pay landowner if > $50,000) | milestone | 0d | 2019-09-06 | 2019-09-06 | 159 | 0d |  | finish no earlier than 2018-10-01 | Fri 9/6/19 |
| 161 | 1.2.5.1.10 | USPS delivers Final offer letter (w/ Return Receipt) |  | 5d | 2019-09-09 | 2019-09-13 | 160 | 0d |  | finish no earlier than 2018-10-01 | Fri 9/13/19 |
| 162 | 1.2.5.1.11 | By law must allow 15 days from RECEIPT of Final offer |  | 11d | 2019-09-16 | 2019-09-30 | 161 | 0d |  | finish no earlier than 2018-10-01 | Mon 9/30/19 |
| 163 | 1.2.5.1.12 | If landowner does not sign within 15 days then goto Condemnation Process | milestone | 0d | 2019-09-30 | 2019-09-30 | 162 | 0d |  | finish no earlier than 2018-10-01 | Mon 9/30/19 |
| 164 | 1.2.5.1.13 | If cost of easement > $50,000 must seek Board approval |  | 18d | 2019-09-09 | 2019-10-02 | 160 | 1049d | 0d | finish no earlier than 2018-10-01 | Wed 10/2/19 |
| 165 | 1.2.5.1.14 | SAWS issues check to landowner |  | 9d | 2019-10-03 | 2019-10-15 | 164 | 1049d | 0d | finish no earlier than 2018-10-01 | Tue 10/15/19 |
| 166 | 1.2.5.1.15 | Some Easements Acquired without condemnation | milestone | 0d | 2019-10-15 | 2019-10-15 | 165 | 1049d |  | finish no earlier than 2018-10-01 | Tue 10/15/19 |

| ID | WBS | Task | Type | Duration | Start | Finish | Predecessors | Total slack | Free slack | Constraint | Baseline Complete |
| --- | --- | --- | --- | --- | --- | --- | --- | --- | --- | --- | --- |
| 167 | 1.2.5.2 | **Real Estate Condemnation Process (each esmt)** |  | 163d | 2019-10-01 | 2020-05-28 |  | 0d |  |  | Thu 5/28/20 |
| 168 | 1.2.5.2.1 | CRE assigns property to a consulting legal firm |  | 5d | 2019-10-01 | 2019-10-07 | 163 | 0d |  |  | Mon 10/7/19 |
| 169 | 1.2.5.2.2 | Attorney reviews case for property |  | 5d | 2019-10-08 | 2019-10-14 | 168 | 0d |  |  | Mon 10/14/19 |
| 170 | 1.2.5.2.3 | Attorney files petition for condemnation |  | 5d | 2019-10-15 | 2019-10-21 | 169 | 0d |  |  | Mon 10/21/19 |
| 171 | 1.2.5.2.4 | Court assigns Commissioners |  | 10d | 2019-10-22 | 2019-11-04 | 170 | 0d |  |  | Mon 11/4/19 |
| 172 | 1.2.5.2.5 | Law allows each party to reject one Commissioner, Court assigns replacement |  | 10d | 2019-11-05 | 2019-11-18 | 171 | 0d |  |  | Mon 11/18/19 |
| 173 | 1.2.5.2.6 | Atty coordinates w/ commissioners, landowner atty, appraisers, etc to schedule hearing. The more condemnations SAWS is pursuing in a given period, the harder to schedule hearings due to availability of commissioners, etc on given day. (75 to 120 days) |  | 75d | 2019-11-19 | 2020-03-12 | 172 | 0d |  |  | Thu 3/12/20 |
| 174 | 1.2.5.2.7 | Landowner asks for continuance (almost always asked and granted) |  | 22d | 2020-03-13 | 2020-04-13 | 173 | 0d |  |  | Mon 4/13/20 |
| 175 | 1.2.5.2.8 | Condemnation Hearing occurs | milestone | 0d | 2020-04-13 | 2020-04-13 | 174 | 718d | 0d |  | Mon 4/13/20 |
| 176 | 1.2.5.2.9 | If cost of easement > $50,000 must seek Board approval |  | 18d | 2020-04-14 | 2020-05-08 | 174 | 0d |  |  | Fri 5/8/20 |
| 177 | 1.2.5.2.10 | SAWS deposits awarded amount in court register |  | 13d | 2020-05-11 | 2020-05-28 | 176 | 0d |  |  | Thu 5/28/20 |
| 178 | 1.2.5.2.11 | All Easements Acquired (SAWS has use of easements) | milestone | 0d | 2020-05-28 | 2020-05-28 | 177 | 0d |  |  | Thu 5/28/20 |
| 179 | 1.2.6 | **Litigation** |  | 390d | 2020-04-14 | 2021-10-28 |  | 718d |  |  | Thu 10/28/21 |
| 180 | 1.2.6.1 | Landowner either accepts or appeals result of Condemnation Hearing |  | 30d | 2020-04-14 | 2020-05-27 | 175 | 718d | 0d |  | Wed 5/27/20 |
| 181 | 1.2.6.2 | If appealed then SAWS CRE, Engr, consulting engrs, attys may spend another year or more in litigation, but SAWS already has use of easement |  | 360d | 2020-05-28 | 2021-10-28 | 180 | 718d |  |  | Thu 10/28/21 |
| 182 | 1.2.7 | **100% Design & Bid Phase** |  | 2783d | 2010-01-04 | 2021-01-27 |  | 911d |  |  | Wed 1/27/21 |
| 183 | 1.2.7.1 | **Final Design** |  | 22d | 2020-03-05 | 2020-04-03 |  | 1097d |  |  | Fri 4/3/20 |
| 184 | 1.2.7.1.1 | Final Design NTP | milestone | 0d | 2020-03-05 | 2020-03-05 | 178FS-59d | 1097d | 0d |  | Thu 3/5/20 |
| 185 | 1.2.7.1.2 | Prepare 100% Bid Documents and Final OPCC |  | 21d | 2020-03-05 | 2020-04-02 | 184 | 1097d | 0d | start no earlier than 2016-09-14 | Thu 4/2/20 |
| 186 | 1.2.7.1.3 | Submit 100% Bid Documents and Final OPCC (Plans,Specs (with draft Front Ends),OPCC,Signed Checklist) |  | 1d | 2020-04-03 | 2020-04-03 | 185 | 1097d | 0d | start no earlier than 2016-09-14 | Fri 4/3/20 |
| 187 | 1.2.7.2 | **SAWS Review of 100% Design** |  | 17d | 2020-04-06 | 2020-04-29 | 186 | 1097d |  |  | Wed 4/29/20 |
| 188 | 1.2.7.2.1 | SAWS Team Distributes to Reviewers (including Construction Dept) |  | 1d | 2020-04-06 | 2020-04-06 |  | 1097d | 0d | start no earlier than 2016-09-14 | Mon 4/6/20 |
| 189 | 1.2.7.2.2 | SAWS Engr Drafts Construction Contract Workflow in CPMS |  | 2d | 2020-04-06 | 2020-04-07 | 186 | 1112d |  |  | Tue 4/7/20 |
| 190 | 1.2.7.2.3 | Consultant Prepares for 100% Workshop |  | 3d | 2020-04-06 | 2020-04-08 | 186 | 1110d | 0d | start no earlier than 2016-09-14 | Wed 4/8/20 |
| 191 | 1.2.7.2.4 | Consultant Conducts 100% Design Workshop (Detail oriented to find and resolve any confusion or questions, no slide presentation) |  | 1d | 2020-04-09 | 2020-04-09 | 190 | 1110d |  | start no earlier than 2016-09-14 | Thu 4/9/20 |
| 192 | 1.2.7.2.5 | SAWS Review of 100% Design |  | 10d | 2020-04-07 | 2020-04-20 | 188 | 1097d | 0d | start no earlier than 2016-09-14 | Mon 4/20/20 |
| 193 | 1.2.7.2.6 | SAWS provides comments to Consultant |  | 1d | 2020-04-21 | 2020-04-21 | 192 | 1097d | 0d | start no earlier than 2016-09-14 | Tue 4/21/20 |
| 194 | 1.2.7.2.7 | Consultant Revises Documents per SAWS Comments |  | 5d | 2020-04-22 | 2020-04-29 | 193 | 1097d |  |  | Wed 4/29/20 |

| ID | WBS | Task | Type | Duration | Start | Finish | Predecessors | Total slack | Constraint | Baseline Complete |
| --- | --- | --- | --- | --- | --- | --- | --- | --- | --- | --- |
| 195 | 1.2.7.3 | **Preparation to Advertise (RFCSP)** |  | 25d | 2020-05-28 | 2020-07-02 |  | 0d |  | Thu 7/2/20 |
| 196 | 1.2.7.3.1 | HOLD Pending Easements, Permits, or Management Direction | milestone | 0d | 2020-05-28 | 2020-05-28 | 178 | 0d | start no earlier than 2019-05-14 | Thu 5/28/20 |
| 197 | 1.2.7.3.2 | Public Meeting with Customers (Scheduled by External Relations) Ideally, include construction contractor so they can provide contact info to area customers. | milestone | 0d | 2020-05-28 | 2020-05-28 | 196 | 1077d |  | Thu 5/28/20 |
| 198 | 1.2.7.3.3 | SAWS Engr Starts RFCSP Construction Contract Workflow in CPMS |  | 1d | 2020-05-29 | 2020-05-29 | 196 | 0d |  | Fri 5/29/20 |
| 199 | 1.2.7.3.4 | Consultant works with SAWS Engr and Mgr to develop Selection Criteria |  | 5d | 2020-05-29 | 2020-06-04 | 196 | 1072d |  | Thu 6/4/20 |
| 200 | 1.2.7.3.5 | SAWS Manager Reviews/Approves proceeding with Construction Contract via CPMS |  | 1d | 2020-06-01 | 2020-06-01 | 198 | 0d |  | Mon 6/1/20 |
| 201 | 1.2.7.3.6 | SAWS Contracting provides RFCSP Front End Documents via CPMS |  | 3d | 2020-06-02 | 2020-06-04 | 200 | 0d |  | Thu 6/4/20 |
| 202 | 1.2.7.3.7 | Consultant incorporates Contracting Front End Documents into Bid Documents |  | 3d | 2020-06-05 | 2020-06-09 | 201 | 0d |  | Tue 6/9/20 |
| 203 | 1.2.7.3.8 | SAWS Contracting Reviews Bid Documents in CPMS |  | 8d | 2020-06-10 | 2020-06-19 | 202 | 0d |  | Fri 6/19/20 |
| 204 | 1.2.7.3.9 | Consultant revises Final Bid Documents |  | 2d | 2020-06-22 | 2020-06-23 | 203 | 0d |  | Tue 6/23/20 |
| 205 | 1.2.7.3.10 | SAWS Contracting Reviews Bid Documents in CPMS |  | 3d | 2020-06-24 | 2020-06-26 | 204 | 0d |  | Fri 6/26/20 |
| 206 | 1.2.7.3.11 | Consultant Prepares 100% Signed/Sealed Bid Documents |  | 2d | 2020-06-29 | 2020-06-30 | 205 | 0d |  | Tue 6/30/20 |
| 207 | 1.2.7.3.12 | Consultant Submits 100% Signed/Sealed Bid Documents to SAWS (to include 10 digital copies on separate disks of each: plans and specs, geotech data, televising) |  | 2d | 2020-07-01 | 2020-07-02 | 206 | 0d |  | Thu 7/2/20 |
| 208 | 1.2.7.3.13 | Final Design Complete (SAWS Engr documents Milestone) | milestone | 0d | 2020-07-02 | 2020-07-02 | 207 | 0d |  | Thu 7/2/20 |
| 209 | 1.2.7.4 | **Permitting** |  | 2705d | 2010-01-04 | 2020-09-30 |  | 989d |  | Wed 9/30/20 |
| 210 | 1.2.7.4.1 | **STATE** |  | 63d | 2020-07-03 | 2020-09-30 |  | 0d |  | Wed 9/30/20 |
| 211 | 1.2.7.4.1.1 | TCEQ EARZ - OSCS Permit (if any part of project is on the EARZ) Consultant submits 100% Plans and ideally meets with TCEQ in person. Await TCEQ Approval BEFORE Advertising |  | 63d | 2020-07-03 | 2020-09-30 | 208 | 0d |  | Wed 9/30/20 |
| 212 | 1.2.7.4.1.2 | TCEQ Public Water System Plan Review (new, modified, or demolition of tank/pump facilities) Consultant sends 100% Plans to TCEQ |  | 63d | 2020-07-03 | 2020-09-30 | 208 | 989d |  | Wed 9/30/20 |
| 213 | 1.2.7.4.1.3 | TCEQ Water Pollution Abatement Plan Review |  | 63d | 2020-07-03 | 2020-09-30 | 208 | 989d |  | Wed 9/30/20 |
| 214 | 1.2.7.4.1.4 | TWDB Loan (requires Environmental + Cultural reports and regulatory review complete) - submit 100% Plans. Await TWDB Approval BEFORE Advertising |  | 63d | 2020-07-03 | 2020-09-30 | 208 | 0d |  | Wed 9/30/20 |
| 215 | 1.2.7.4.2 | **COUNTY** |  | 21d | 2010-01-04 | 2010-02-02 |  | 3673d |  | Tue 2/2/10 |
| 216 | 1.2.7.4.2.1 | Bexar County Right-of-Way Permit (expires in 180 days) (renewal by contractor) |  | 21d | 2010-01-04 | 2010-02-02 |  | 3673d |  | Tue 2/2/10 |
| 217 | 1.2.7.4.2.2 | Bexar County Floodplain Permit (expires in 180 days)(renewal by contractor) |  | 21d | 2010-01-04 | 2010-02-02 |  | 3673d |  | Tue 2/2/10 |
| 218 | 1.2.7.4.2.3 | Bexar Stormwater Quality Site Development Permit (expiration based on project duration) |  | 21d | 2010-01-04 | 2010-02-02 |  | 3673d |  | Tue 2/2/10 |

| ID | WBS | Task | Type | Duration | Start | Finish | Predecessors | Total slack | Constraint | Baseline Complete |
| --- | --- | --- | --- | --- | --- | --- | --- | --- | --- | --- |
| 219 | 1.2.7.4.3 | **CITY** |  | 10d | 2010-01-04 | 2010-01-15 |  | 3684d |  | Fri 1/15/10 |
| 220 | 1.2.7.4.3.1 | CoSA Flood Plain Permit (expires in 2 years) |  | 10d | 2010-01-04 | 2010-01-15 |  | 3684d |  | Fri 1/15/10 |
| 221 | 1.2.7.4.4 | Consultant Updates Permit Log as Design Progresses |  | 60d | 2020-07-08 | 2020-09-30 | 211FF | 989d |  | Wed 9/30/20 |
| 222 | 1.2.7.4.5 | 100% Coordination Meetings with Utilities, Permit Agencies, and other Stakeholders |  | 15d | 2010-01-04 | 2010-01-25 |  | 3679d |  | Mon 1/25/10 |
| 223 | 1.2.7.4.6 | Consultant Updates Utility and Stakeholder Coordination Log |  | 15d | 2010-01-04 | 2010-01-25 |  | 3679d |  | Mon 1/25/10 |
| 224 | 1.2.7.5 | **Advertise (RFCSP)** |  | 63d | 2020-09-30 | 2021-01-05 |  | 0d |  | Tue 1/5/21 |
| 225 | 1.2.7.5.1 | HOLD Pending Final Permits or Management Direction | milestone | 0d | 2020-09-30 | 2020-09-30 | 208, 211, 214 | 0d |  | Wed 9/30/20 |
| 226 | 1.2.7.5.2 | SAWS Engr Drafts and submits Board Item (with blanks) | milestone | 0d | 2020-09-30 | 2020-09-30 | 225 | 989d |  | Wed 9/30/20 |
| 227 | 1.2.7.5.3 | Advertise Solicitation (Monday, Wednesday, or Friday) | milestone | 0d | 2020-09-30 | 2020-09-30 | 225 | 0d | start no earlier than 2019-05-14 | Wed 9/30/20 |
| 228 | 1.2.7.5.4 | Advertise at least twice in publication (2nd exactly one week after 1st) |  | 9d | 2020-10-01 | 2020-10-13 | 227 | 0d |  | Tue 10/13/20 |
| 229 | 1.2.7.5.5 | Pre-Solicitation Meeting (non-mandatory, ideally two weeks after advertisement) |  | 1d | 2020-10-14 | 2020-10-14 | 228 | 0d |  | Wed 10/14/20 |
| 230 | 1.2.7.5.6 | Questions Deadline (Ideally 7 days after meeting) |  | 5d | 2020-10-15 | 2020-10-21 | 229 | 0d |  | Wed 10/21/20 |
| 231 | 1.2.7.5.7 | Final Addendum |  | 5d | 2020-10-22 | 2020-10-28 | 230 | 0d |  | Wed 10/28/20 |
| 232 | 1.2.7.5.8 | Respondents Finalize Proposals (Ideally 2 weeks after final addendum) |  | 10d | 2020-10-29 | 2020-11-11 | 231 | 0d |  | Wed 11/11/20 |
| 233 | 1.2.7.5.9 | Contracting reads Price Proposals to public (NO SAWS engineering staff may be present) [overall advertisement period must be at least 21 calendar days (30 days if TWDB), SAWS prefers 42 days for RFCSP] | milestone | 0d | 2020-11-11 | 2020-11-11 | 232 | 0d |  | Wed 11/11/20 |
| 234 | 1.2.7.5.10 | Contracting distributes and then obtains signed Code of Conduct forms with members of Technical Committee |  | 1d | 2020-11-12 | 2020-11-12 | 233 | 0d |  | Thu 11/12/20 |
| 235 | 1.2.7.5.11 | Technical Committee Evaluates Submittals |  | 5d | 2020-11-13 | 2020-11-19 | 234 | 0d |  | Thu 11/19/20 |
| 236 | 1.2.7.5.12 | Technical Committee Concurrence Meeting |  | 1d | 2020-11-20 | 2020-11-20 | 235 | 0d |  | Fri 11/20/20 |
| 237 | 1.2.7.5.13 | Technical Committee provides scores to Contracting |  | 1d | 2020-11-23 | 2020-11-23 | 236 | 0d |  | Mon 11/23/20 |
| 238 | 1.2.7.5.14 | Contracting shares Technical Committee scores with Selection Committee |  | 1d | 2020-11-24 | 2020-11-24 | 237 | 0d |  | Tue 11/24/20 |
| 239 | 1.2.7.5.15 | Selection Committee Reviews Tech Committee Scores |  | 3d | 2020-11-25 | 2020-12-01 | 238 | 0d |  | Tue 12/1/20 |
| 240 | 1.2.7.5.16 | Selection Committee Meets to Select Contractor |  | 1d | 2020-12-02 | 2020-12-02 | 239 | 0d |  | Wed 12/2/20 |
| 241 | 1.2.7.5.17 | Contracting/Selection Committee provide recommendation to CEO/Exec Mgmt |  | 1d | 2020-12-03 | 2020-12-03 | 240 | 0d |  | Thu 12/3/20 |
| 242 | 1.2.7.5.18 | CEO/Exec Mgmt Reviews Recommendation |  | 3d | 2020-12-04 | 2020-12-08 | 241 | 0d |  | Tue 12/8/20 |
| 243 | 1.2.7.5.19 | Contracting/Selection Committee confirm course of action |  | 1d | 2020-12-09 | 2020-12-09 | 242 | 0d |  | Wed 12/9/20 |
| 244 | 1.2.7.5.20 | Contracting Informs SAWS Engr of Selected Contractor, Amount, SMWVB info |  | 2d | 2020-12-10 | 2020-12-11 | 243 | 0d |  | Fri 12/11/20 |
| 245 | 1.2.7.5.21 | SAWS Engr and Manager Submit Final Board Item |  | 1d | 2020-12-14 | 2020-12-14 | 244 | 0d |  | Mon 12/14/20 |
| 246 | 1.2.7.5.22 | SAWS Management, Legal, Contracting Review (may be longer than expected if this task falls on a holiday or otherwise has to align with actual Board Date (1st Tuesday)) |  | 12d | 2020-12-15 | 2021-01-05 | 245 | 0d |  | Tue 1/5/21 |
| 247 | 1.2.7.5.23 | Board Award Construction (1st Tuesday of Month) =< 60 days from reading of Price Proposals | milestone | 0d | 2021-01-05 | 2021-01-05 | 246 | 0d |  | Tue 1/5/21 |

| ID | WBS | Task | Type | Duration | Start | Finish | Predecessors | Total slack | Free slack | Constraint | Baseline Complete |
| --- | --- | --- | --- | --- | --- | --- | --- | --- | --- | --- | --- |
| 248 | 1.2.7.6 | **Contract Execution** |  | 15d | 2021-01-06 | 2021-01-27 | 247 | 0d |  |  | Wed 1/27/21 |
| 249 | 1.2.7.6.1 | Construction Contract Execution (SAWS Engr documents Milestone) |  | 7d | 2021-01-06 | 2021-01-14 |  | 0d |  |  | Thu 1/14/21 |
| 250 | 1.2.7.6.2 | Contracting Schedules Pre-Con Meeting |  | 7d | 2021-01-15 | 2021-01-26 | 249 | 0d |  |  | Tue 1/26/21 |
| 251 | 1.2.7.6.3 | Pre-Con Meeting |  | 1d | 2021-01-27 | 2021-01-27 | 250 | 0d |  |  | Wed 1/27/21 |
| 252 | 1.3 | **CONSTRUCTION** |  | 404d | 2021-01-27 | 2022-08-31 |  | 0d |  |  | Wed 8/31/22 |
| 253 | 1.3.1 | Construction NTP | milestone | 0d | 2021-01-27 | 2021-01-27 | 251 | 0d |  | start no earlier than 2020-03-09 | Wed 1/27/21 |
| 254 | 1.3.2 | Submittals |  | 21d | 2021-01-28 | 2021-02-25 | 253 | 0d |  | start no earlier than 2020-03-10 | Thu 2/25/21 |
| 255 | 1.3.3 | 30% Construction Duration |  | 120d | 2021-02-26 | 2021-08-16 | 254 | 0d |  | start no earlier than 2020-03-10 | Mon 8/16/21 |
| 256 | 1.3.4 | 30% Construction Complete (SAWS Engr documents Milestone) | milestone | 0d | 2021-08-16 | 2021-08-16 | 255 | 0d |  | start no earlier than 2020-03-10 | Mon 8/16/21 |
| 257 | 1.3.5 | 60% Construction Duration |  | 120d | 2021-08-17 | 2022-02-08 | 256 | 0d |  | start no earlier than 2020-03-10 | Tue 2/8/22 |
| 258 | 1.3.6 | 60% Construction Complete (SAWS Engr documents Milestone) | milestone | 0d | 2022-02-08 | 2022-02-08 | 257 | 0d |  | start no earlier than 2020-03-10 | Tue 2/8/22 |
| 259 | 1.3.7 | Final Construction Duration |  | 120d | 2022-02-09 | 2022-07-29 | 258 | 0d |  | start no earlier than 2020-03-10 | Fri 7/29/22 |
| 260 | 1.3.8 | Final Walkthrough |  | 2d | 2022-08-01 | 2022-08-02 | 259 | 0d |  | start no earlier than 2022-03-01 | Tue 8/2/22 |
| 261 | 1.3.9 | Contractor Completes Punchlist |  | 21d | 2022-08-03 | 2022-08-31 | 260 | 0d |  | start no earlier than 2022-03-07 | Wed 8/31/22 |
| 262 | 1.3.10 | Final Completion (FFAC COMPLETE) (SAWS Engr documents Milestone) | milestone | 0d | 2022-08-31 | 2022-08-31 | 261 | 0d |  |  | Wed 8/31/22 |
| 263 | 1.4 | EPA Deadline | milestone | 0d | 2023-07-23 | 2023-07-23 |  | 282d |  | start no earlier than 2023-07-23 | Sun 7/23/23 |
| 264 | 1.5 | **CONTRACTS CLOSEOUT** |  | 507d | 2022-09-01 | 2024-09-03 |  | 0d |  |  | Tue 9/3/24 |
| 265 | 1.5.1 | Contracting + Construction Develop RECAP Change Order |  | 77d | 2022-09-01 | 2022-12-21 | 262 | 430d | 0d |  | Wed 12/21/22 |
| 266 | 1.5.2 | No RECAP Board Item anymore -per Board Res 18-076 | milestone | 0d | 2022-12-21 | 2022-12-21 | 265 | 430d |  |  | Wed 12/21/22 |
| 267 | 1.5.3 | Post Televising Submittal via CPMS (by Inspections) |  | 15d | 2022-09-01 | 2022-09-22 | 262 | 492d |  |  | Thu 9/22/22 |
| 268 | 1.5.4 | Redlines Finalized |  | 30d | 2022-09-01 | 2022-10-13 | 262 | 392d | 0d | finish no earlier than 2018-08-09 | Thu 10/13/22 |
| 269 | 1.5.5 | Redlines Submitted via CPMS (by Contractor) | milestone | 0d | 2022-10-13 | 2022-10-13 | 268 | 477d |  | start no earlier than 2018-08-09 | Thu 10/13/22 |
| 270 | 1.5.6 | Redlines Submitted via CPMS (by Inspector) | milestone | 0d | 2022-10-13 | 2022-10-13 | 268 | 477d |  | start no earlier than 2018-08-09 | Thu 10/13/22 |
| 271 | 1.5.7 | Redlines Compiled into Record Drawings (by Consultant) |  | 15d | 2022-10-14 | 2022-11-03 | 268 | 392d | 0d | finish no earlier than 2018-09-07 | Thu 11/3/22 |
| 272 | 1.5.8 | Record Drawings Submittal via CPMS (by Consultant) | milestone | 0d | 2022-11-03 | 2022-11-03 | 271 | 392d | 0d | start no earlier than 2018-09-07 | Thu 11/3/22 |
| 273 | 1.5.9 | Record Drawings Initial Review (by Senior Tech) |  | 10d | 2022-11-04 | 2022-11-17 | 272 | 392d | 0d | finish no earlier than 2018-09-21 | Thu 11/17/22 |
| 274 | 1.5.10 | Record Drawings Revision (by Consultant) |  | 5d | 2022-11-18 | 2022-11-28 | 273 | 392d | 0d | finish no earlier than 2018-10-03 | Mon 11/28/22 |
| 275 | 1.5.11 | Record Drawings 2nd Review (by Senior Tech) |  | 10d | 2022-11-29 | 2022-12-12 | 274 | 392d | 0d | finish no earlier than 2018-10-17 | Mon 12/12/22 |
| 276 | 1.5.12 | Record Drawings CPMS Submit for Final Review (by Consultant) |  | 5d | 2022-12-13 | 2022-12-19 | 275 | 392d | 0d | finish no earlier than 2018-10-24 | Mon 12/19/22 |
| 277 | 1.5.13 | Record Drawings CPMS EIT Final Review |  | 5d | 2022-12-20 | 2022-12-26 | 276 | 392d | 0d | finish no earlier than 2018-10-31 | Mon 12/26/22 |
| 278 | 1.5.14 | Record Drawings CPMS PE Final Review |  | 5d | 2022-12-27 | 2023-01-02 | 277 | 392d | 0d | finish no earlier than 2018-11-07 | Mon 1/2/23 |
| 279 | 1.5.15 | Record Drawings Review Complete | milestone | 0d | 2023-01-02 | 2023-01-02 | 278 | 392d | 0d | start no earlier than 2018-11-07 | Mon 1/2/23 |
| 280 | 1.5.16 | Mapping Process |  | 10d | 2023-01-03 | 2023-01-17 | 279 | 392d | 0d | finish no earlier than 2018-11-14 | Tue 1/17/23 |
| 281 | 1.5.17 | Mapping Complete | milestone | 0d | 2023-01-17 | 2023-01-17 | 280 | 392d | 0d | start no earlier than 2018-11-14 | Tue 1/17/23 |
| 282 | 1.5.18 | Process Last Consultant Invoice |  | 5d | 2023-01-18 | 2023-01-24 | 281 | 392d | 0d |  | Tue 1/24/23 |
| 283 | 1.5.19 | Verify ALL Design and Construction closeout documentation is complete |  | 10d | 2023-01-25 | 2023-02-07 | 282 | 392d | 0d |  | Tue 2/7/23 |
| 284 | 1.5.20 | Review CPMS Closeout TAB, update with relevant information |  | 3d | 2023-02-08 | 2023-02-10 | 283 | 392d | 0d |  | Fri 2/10/23 |
| 285 | 1.5.21 | IF ALL Construction Closeout Documents Complete & Archived, press Construction Complete in CPMS |  | 1d | 2023-02-13 | 2023-02-13 | 284 | 392d | 0d |  | Mon 2/13/23 |
| 286 | 1.5.22 | IF ALL Design Closeout Documents Complete & Archived, press Design Complete in CPMS |  | 1d | 2023-02-14 | 2023-02-14 | 285 | 392d |  |  | Tue 2/14/23 |
| 287 | 1.5.23 | WARRANTY PERIOD |  | 507d | 2022-09-01 | 2024-09-03 | 262 | 0d |  |  | Tue 9/3/24 |
